# SRF Infra Plan-v1

Schedule from MS Project, 2006-10-02 to 2012-07-03, costs in $.
Fermilab

## Calendars

- Standard: Mon-Fri 08:00-12:00, 13:00-17:00; Sat-Sun off.

## Resources

| Resource | Rate |
| --- | --- |
| M&S Cost | 1000 |

## Schedule

| ID | WBS | Task | Type | Duration | Start | Finish | Predecessors | Total slack | Free slack | Constraint | Cost |
| --- | --- | --- | --- | --- | --- | --- | --- | --- | --- | --- | --- |
| 1 | 1 | **SRF Infrastructure Plan** |  | 1501.8d | 2006-10-02 | 2012-07-03 |  | 0d |  |  | 89,299.45 |
| 2 | 1.1 | **Cavity Fabrication Infrastructure** |  | 569d | 2006-10-02 | 2008-12-04 |  | 932.8d |  |  | 3,695 |
| 3 | 1.1.1 | Cavity Fab Infra FY07 Finish Procurements |  | 52w | 2006-10-02 | 2007-09-28 |  | 1241.8d |  |  | 200 |
| 4 | 1.1.2 | Order Scanner, US Cleaner, CR HW |  | 10mo | 2007-10-02 | 2008-08-04 |  | 1020.8d | 0d | start no earlier than 2007-10-02 | 699 |
| 5 | 1.1.3 | Cavity Fab Infra Ready for Operation | milestone | 0d | 2008-08-04 | 2008-08-04 | 4 | 1020.8d |  |  |  |
| 6 | 1.1.4 | Order EB Welder |  | 15mo | 2007-08-31 | 2008-12-04 |  | 932.8d | 0d | start no earlier than 2007-08-31 | 2,796 |
| 7 | 1.1.5 | EB Welder Ready for Operation | milestone | 0d | 2008-12-04 | 2008-12-04 | 6 | 932.8d |  |  |  |
| 8 | 1.2 | **Cavity Processing Facilities** |  | 1140d | 2006-10-02 | 2011-02-11 |  | 361.8d |  |  | 13,682 |
| 9 | 1.2.1 | BCP & EP @ ANL FY07 Finish Procurements |  | 52w | 2006-10-02 | 2007-09-28 |  | 1241.8d |  |  | 750 |
| 10 | 1.2.2 | Complete CPF Layout & Establish Requirements |  | 6mo | 2007-01-02 | 2007-07-04 |  | 557.8d | 0d | start no earlier than 2007-01-02 |  |
| 11 | 1.2.3 | Building Selection & Prep |  | 3mo | 2007-10-05 | 2008-01-04 | 10FS+3mo | 557.8d | 0d |  | 582 |
| 12 | 1.2.4 | CFS Evaluation & Safety Review |  | 4mo | 2007-12-06 | 2008-04-07 | 11FS-1mo | 1105.8d |  |  |  |
| 13 | 1.2.5 | Design/Specify HPR, UPW & Scrubber Systems |  | 9mo | 2007-01-02 | 2007-10-04 |  | 711.8d | 0d | start no earlier than 2007-01-02 |  |
| 14 | 1.2.6 | Procure Clean Room |  | 5mo | 2008-10-07 | 2009-03-09 | 11 | 361.8d | 0d | start no earlier than 2008-10-07 | 1,165 |
| 15 | 1.2.7 | Install Clean Room & Hardware |  | 5mo | 2009-03-10 | 2009-08-10 | 14 | 361.8d | 0d |  | 175 |
| 16 | 1.2.8 | Procure HPR, UPW & Scrubbber Systems |  | 8mo | 2008-12-08 | 2009-08-10 | 15FF | 361.8d | 0d |  | 816 |
| 17 | 1.2.9 | Begin Adding Extra Capacity to CPF | milestone | 0d | 2010-04-26 | 2010-04-26 | 29 | 361.8d | 0d | start no earlier than 2009-10-01 |  |
| 18 | 1.2.10 | Procure 2 more HPR Systems |  | 6mo | 2010-04-27 | 2010-10-27 | 17 | 361.8d | 0d |  | 932 |
| 19 | 1.2.11 | Procure First Set BCP & EP Cabinets |  | 6mo | 2007-10-05 | 2008-04-07 | 10, 13 | 711.8d | 350d | start no earlier than 2007-10-02 | 1,204 |
| 20 | 1.2.12 | Procure Remainder BCP & EP Cabinets |  | 6mo | 2010-04-27 | 2010-10-27 | 17 | 361.8d | 0d |  | 1,825 |
| 21 | 1.2.13 | Procure First Set Auxilliary Equipment |  | 6mo | 2009-02-06 | 2009-08-10 | 19FF, 16FF | 361.8d | 0d |  | 1,835 |
| 22 | 1.2.14 | Procure Remainder Auxilliary Equipment |  | 6mo | 2010-04-27 | 2010-10-27 | 20FF, 18FF | 361.8d | 0d |  | 1,835 |
| 23 | 1.2.15 | Install First Set Equipment |  | 3mo | 2009-06-30 | 2009-09-29 | 21FS-6w | 361.8d | 0d |  | 2,563 |
| 24 | 1.2.16 | Precommisiioon Systems |  | 3mo | 2009-09-30 | 2009-12-30 | 23 | 653.8d |  |  |  |
| 25 | 1.2.17 | Prepare Docs for Safety Review |  | 8mo | 2009-01-27 | 2009-09-29 | 23FF | 361.8d | 0d |  |  |
| 26 | 1.2.18 | Conduct Safety Review |  | 4mo | 2009-09-30 | 2010-01-29 | 25 | 361.8d | 0d |  |  |
| 27 | 1.2.19 | Obtain ORC |  | 1mo | 2010-01-25 | 2010-02-23 | 26FS-1w | 361.8d | 0d |  |  |
| 28 | 1.2.20 | Commission Facility |  | 2mo | 2010-02-24 | 2010-04-26 | 27 | 361.8d | 0d |  |  |
| 29 | 1.2.21 | CPF First Set Ready for Operation | milestone | 0d | 2010-04-26 | 2010-04-26 | 28 | 361.8d | 0d |  |  |
| 30 | 1.2.22 | Full CPF Ready for Operation | milestone | 0d | 2011-02-11 | 2011-02-11 | 22FS+3.5mo | 361.8d |  |  |  |

| ID | WBS | Task | Type | Duration | Start | Finish | Predecessors | Total slack | Free slack | Constraint | Cost |
| --- | --- | --- | --- | --- | --- | --- | --- | --- | --- | --- | --- |
| 31 | 1.3 | **Vertical Test Stand (VTS2 & VTS3)** |  | 781d | 2006-10-02 | 2009-09-28 |  | 720.8d |  |  | 3,738 |
| 32 | 1.3.1 | VTS 1 FY07 Finish Procurements |  | 39w | 2006-10-02 | 2007-06-29 |  | 800.8d | 21d |  | 680 |
| 33 | 1.3.2 | VTS 1 Ready for Operation | milestone | 0d | 2007-07-31 | 2007-07-31 | 32 | 779.8d | 0d | start no earlier than 2007-07-31 |  |
| 34 | 1.3.3 | Procure Parts for 2 Cavity Operation |  | 6mo | 2007-07-31 | 2008-01-30 | 33 | 1153.8d |  |  | 87 |
| 35 | 1.3.4 | Design Cryo System Upgrade |  | 9mo | 2007-07-31 | 2008-05-01 | 33 | 779.8d | 0d |  |  |
| 36 | 1.3.5 | Procure Long Lead Parts for Cryo Sys Upgrade |  | 6mo | 2008-01-01 | 2008-07-02 | 35FS-4mo | 779.8d | 0d |  | 1,205 |
| 37 | 1.3.6 | Procure Final Parts for Cryo Sys Upgrade |  | 3mo | 2008-07-03 | 2008-10-02 | 36 | 779.8d | 0d |  | 252 |
| 38 | 1.3.7 | Install & Commission Cryo System Upgrade |  | 6mo | 2008-10-03 | 2009-04-06 | 37 | 779.8d | 0d |  |  |
| 39 | 1.3.8 | CryoSystem Upgrade Complete | milestone | 0d | 2009-04-06 | 2009-04-06 | 38 | 845.8d |  |  |  |
| 40 | 1.3.9 | Begin VTS 2 & 3 Tasks | milestone | 0d | 2008-10-01 | 2008-10-01 |  | 720.8d | 0d | start no earlier than 2008-10-01 |  |
| 41 | 1.3.10 | Design Rad Shielding for VTS 2 & 3 |  | 6mo | 2007-03-01 | 2007-08-31 |  | 1068.8d | 348d | start no earlier than 2007-03-01 |  |
| 42 | 1.3.11 | Design VTS 2 & 3 System |  | 3mo | 2008-10-01 | 2008-12-31 | 35, 40 | 720.8d | 0d |  |  |
| 43 | 1.3.12 | Procure Parts for VTS 2 & 3 |  | 6mo | 2009-01-01 | 2009-07-03 | 42, 41 | 720.8d | 0d | start no earlier than 2008-10-01 | 1,160 |
| 44 | 1.3.13 | Install & Commission VTS 2 & 3 |  | 3mo | 2009-06-29 | 2009-09-28 | 43FS-1w, 38 | 720.8d | 0d |  | 354 |
| 45 | 1.3.14 | VTS 2 & 3 Ready for Operation | milestone | 0d | 2009-09-28 | 2009-09-28 | 44 | 720.8d |  | start no earlier than 2008-12-19 |  |
| 46 | 1.4 | **Horizontal Test Stand (HTS2)** |  | 836d | 2006-10-02 | 2009-12-14 |  | 665.8d |  |  | 2,021 |
| 47 | 1.4.1 | HTS 1 FY07 Finish Procurements |  | 52w | 2006-10-02 | 2007-09-28 |  | 1241.8d |  |  | 600 |
| 48 | 1.4.2 | HTS 1 Commissioning Run |  | 2.5mo | 2007-02-01 | 2007-04-18 |  | 1138.8d | 51d | start no earlier than 2007-02-01 |  |
| 49 | 1.4.3 | Install 3.9 GHz Klystron in MDB (HTS1) | milestone | 0d | 2007-06-29 | 2007-06-29 |  | 1087.8d | 0d | start no earlier than 2007-06-29 |  |
| 50 | 1.4.4 | HTS 1 Ready for Operation | milestone | 0d | 2007-06-29 | 2007-06-29 | 48, 49 | 1087.8d | 0d |  |  |
| 51 | 1.4.5 | Test 3.9 GHz & 1.3 GHz Cavities (CM2) |  | 10mo | 2007-06-29 | 2008-05-01 | 50 | 1087.8d |  |  |  |
| 52 | 1.4.6 | Design HTS 2 |  | 3mo | 2008-10-01 | 2008-12-31 |  | 665.8d | 0d | start no earlier than 2008-10-01 |  |
| 53 | 1.4.7 | Procure Long Lead Parts for HTS 2 |  | 6mo | 2008-12-25 | 2009-06-26 | 52FS-1w | 665.8d | 0d |  | 1,060 |
| 54 | 1.4.8 | Prepare Infrastructure & Install HTS 2 |  | 4mo | 2009-05-28 | 2009-09-28 | 53FS-1mo | 665.8d | 0d |  | 361 |
| 55 | 1.4.9 | HTS 2 Commissioning Run |  | 2.5mo | 2009-09-29 | 2009-12-14 | 54 | 665.8d | 0d | start no earlier than 2007-02-01 |  |
| 56 | 1.4.10 | HTS 2 Ready for Operation | milestone | 0d | 2009-12-14 | 2009-12-14 | 55 | 665.8d |  |  |  |

| ID | WBS | Task | Type | Duration | Start | Finish | Predecessors | Total slack | Free slack | Constraint | Cost |
| --- | --- | --- | --- | --- | --- | --- | --- | --- | --- | --- | --- |
| 57 | 1.5 | **Cavity/Cryomodule Assembly Facilities** |  | 937d | 2006-10-02 | 2010-05-04 |  | 564.8d |  |  | 1,570 |
| 58 | 1.5.1 | CAF FY07 Finish Procurements |  | 52w | 2006-10-02 | 2007-09-28 |  | 1241.8d |  |  | 766 |
| 59 | 1.5.2 | CAF-MP9 Ready for Operation (R&D) | milestone | 0d | 2007-02-28 | 2007-02-28 |  | 1328.8d | 0d | start no earlier than 2007-02-28 |  |
| 60 | 1.5.3 | HPR Final Design Complete | milestone | 0d | 2007-06-01 | 2007-06-01 |  | 1239.8d | 0d | start no earlier than 2007-06-01 |  |
| 61 | 1.5.4 | CAF-MP9 HPR & TIG Welding (Dress Cav) |  | 4mo | 2007-06-01 | 2007-10-02 | 60 | 1239.8d |  |  | 385 |
| 62 | 1.5.5 | CAF-ICB Ready for Operation (R&D) | milestone | 0d | 2007-04-27 | 2007-04-27 |  | 1352.8d |  | start no earlier than 2007-04-27 |  |
| 63 | 1.5.6 | Practice Assembly Techniques |  | 3mo | 2007-02-28 | 2007-05-30 | 59 | 1328.8d |  |  |  |
| 64 | 1.5.7 | Begin CM1 Assembly | milestone | 0d | 2007-07-05 | 2007-07-05 |  | 1127.8d | 0d | start no earlier than 2007-07-05 |  |
| 65 | 1.5.8 | CM1 Assembly |  | 4mo | 2007-07-05 | 2007-11-05 | 64 | 1127.8d | 0d |  |  |
| 66 | 1.5.9 | CM1 Complete | milestone | 0d | 2007-11-05 | 2007-11-05 | 65 | 1127.8d | 0d |  |  |
| 67 | 1.5.10 | Practice Assembly of 3.9 GHz |  | 3mo | 2007-03-01 | 2007-05-31 |  | 1327.8d |  | start no earlier than 2007-03-01 |  |
| 68 | 1.5.11 | 3.9 GHz String Assembly |  | 0.5mo | 2007-11-30 | 2007-12-14 |  | 1142.8d | 0d | start no earlier than 2007-11-30 |  |
| 69 | 1.5.12 | CM 3.9 Assembly |  | 2mo | 2007-12-17 | 2008-02-14 | 68 | 1142.8d | 0d |  |  |
| 70 | 1.5.13 | 3.9 GHz Ready to Ship to DESY | milestone | 0d | 2008-02-14 | 2008-02-14 | 69 | 1142.8d |  |  |  |
| 71 | 1.5.14 | Begin CM2 Assembly | milestone | 0d | 2008-02-01 | 2008-02-01 |  | 932.8d | 0d | start no earlier than 2008-02-01 |  |
| 72 | 1.5.15 | CM2 Assembly |  | 3mo | 2008-02-01 | 2008-05-02 | 71 | 932.8d | 0d |  |  |
| 73 | 1.5.16 | CM2 Complete | milestone | 0d | 2008-05-02 | 2008-05-02 | 72 | 932.8d | 0d |  |  |
| 74 | 1.5.17 | Begin CAF Upgrades | milestone | 0d | 2009-10-01 | 2009-10-01 | 73 | 564.8d | 0d | start no earlier than 2009-10-01 |  |
| 75 | 1.5.18 | Design CAF Upgrades (1 CM/mo) |  | 3mo | 2009-10-01 | 2009-12-31 | 74 | 564.8d | 0d |  |  |
| 76 | 1.5.19 | Procure CAF Upgrades |  | 3mo | 2010-01-01 | 2010-04-02 | 75 | 564.8d | 0d | start no earlier than 2008-10-01 | 419 |
| 77 | 1.5.20 | Install CAF Upgrades |  | 1mo | 2010-04-05 | 2010-05-04 | 76 | 564.8d | 0d |  |  |
| 78 | 1.5.21 | CAF Ready for 1CM/month Operation | milestone | 0d | 2010-05-04 | 2010-05-04 | 77 | 564.8d |  |  |  |
| 79 | 1.6 | **Cryomodule Test Stand** |  | 594d | 2009-10-01 | 2012-01-10 |  | 124.8d |  |  | 6,291 |
| 80 | 1.6.1 | Design CTS |  | 6mo | 2009-10-01 | 2010-04-02 | 92, 109 | 124.8d | 0d | start no earlier than 2009-10-01 |  |
| 81 | 1.6.2 | Procure Cryo Parts for CTS |  | 12mo | 2010-04-05 | 2011-04-07 | 80 | 124.8d | 0d |  | 4,893 |
| 82 | 1.6.3 | Procure RF Parts for CTS |  | 8mo | 2010-04-05 | 2010-12-06 | 80 | 212.8d | 0d |  | 1,398 |
| 83 | 1.6.4 | Install CTS |  | 9mo | 2011-04-08 | 2012-01-10 | 82, 81 | 124.8d | 0d |  |  |
| 84 | 1.6.5 | CTS Ready for Operation | milestone | 0d | 2012-01-10 | 2012-01-10 | 83 | 124.8d |  |  |  |

| ID | WBS | Task | Type | Duration | Start | Finish | Predecessors | Total slack | Free slack | Constraint | Cost |
| --- | --- | --- | --- | --- | --- | --- | --- | --- | --- | --- | --- |
| 85 | 1.7 | **NML Facility** |  | 782d | 2006-10-02 | 2009-09-29 |  | 719.8d |  |  | 21,285 |
| 86 | 1.7.1 | NML FY07 Procurements CM related |  | 52w | 2006-10-02 | 2007-09-28 |  | 1241.8d |  |  | 3,900 |
| 87 | 1.7.2 | NML FY07 Procurements Accel related |  | 52w | 2006-10-02 | 2007-09-28 |  | 1241.8d |  | start no earlier than 2006-10-02 | 853 |
| 88 | 1.7.3 | Building Infrastructure Complete | milestone | 0d | 2007-08-15 | 2007-08-15 |  | 1274.8d |  | start no earlier than 2007-08-15 |  |
| 89 | 1.7.4 | 300 Kw & 5Mw Klystrons Installed & Operational | milestone | 0d | 2007-09-28 | 2007-09-28 |  | 1198.8d | 71d | start no earlier than 2007-09-28 |  |
| 90 | 1.7.5 | CM1 Delivery to NML | milestone | 0d | 2007-11-05 | 2007-11-05 | 66 | 1127.8d | 0d |  |  |
| 91 | 1.7.6 | Install & Prep CM1 |  | 2mo | 2007-11-06 | 2008-01-04 | 90 | 1127.8d | 0d |  |  |
| 92 | 1.7.7 | Cryo System Installed & Commissioned | milestone | 0d | 2008-03-03 | 2008-03-03 |  | 537.8d | 0d | start no earlier than 2008-03-03 |  |
| 93 | 1.7.8 | Cryo & RF Systems Operational | milestone | 0d | 2008-03-03 | 2008-03-03 | 89, 92, 91 | 1087.8d | 0d |  |  |
| 94 | 1.7.9 | Begin CM1 Warm RF Test | milestone | 0d | 2008-03-03 | 2008-03-03 | 93 | 1087.8d | 0d | start no earlier than 2008-01-15 |  |
| 95 | 1.7.10 | Begin CM1 Cooldown & Test | milestone | 0d | 2008-05-01 | 2008-05-01 | 94FS+2mo | 1087.8d |  |  |  |
| 96 | 1.7.11 | NML FY08 Procurements CM related |  | 52w | 2007-10-02 | 2008-09-29 |  | 980.8d |  | start no earlier than 2007-10-02 | 5,550 |
| 97 | 1.7.12 | NML FY08 High Priority Procurements Accel related |  | 52w | 2007-10-01 | 2008-09-26 |  | 981.8d |  | start no earlier than 2007-10-01 | 1,650 |
| 98 | 1.7.13 | NML FY08/09 Procurements Accel related -Delayed |  | 52w | 2008-10-01 | 2009-09-29 |  | 719.8d |  | start no earlier than 2008-10-01 | 5,462 |
| 99 | 1.7.14 | Begin Move of A0 Injector & RF System to NML | milestone | 0d | 2008-02-01 | 2008-02-01 |  | 1152.8d |  | start no earlier than 2008-02-01 |  |
| 100 | 1.7.15 | CM2 Delivery to NML | milestone | 0d | 2008-05-02 | 2008-05-02 | 73 | 932.8d | 0d |  |  |
| 101 | 1.7.16 | Install & Prep CM2 |  | 2mo | 2008-05-05 | 2008-07-03 | 100 | 932.8d | 61d |  |  |
| 102 | 1.7.17 | Install 10 Mw Klystron (procured by SLAC) | milestone | 0d | 2008-09-26 | 2008-09-26 |  | 872.8d | 1d | start no earlier than 2008-09-26 |  |
| 103 | 1.7.18 | NML Phase 2 Cryo Ready for Operation | milestone | 0d | 2008-09-29 | 2008-09-29 |  | 200.8d | 0d | start no earlier than 2008-09-29 |  |
| 104 | 1.7.19 | Install & Prep for First Beam |  | 5mo | 2008-09-29 | 2009-02-27 | 103, 101, 102 | 871.8d | 0d |  |  |
| 105 | 1.7.20 | First Beam in NML | milestone | 0d | 2009-02-27 | 2009-02-27 | 104 | 871.8d |  |  |  |
| 106 | 1.7.21 | NML FY09 Procurements CM related |  | 52w | 2008-10-01 | 2009-09-29 |  | 719.8d |  | start no earlier than 2008-10-01 | 2,330 |
| 107 | 1.7.22 | NML FY09 Procurements Accel related |  | 52w | 2008-10-01 | 2009-09-29 |  | 719.8d |  | start no earlier than 2008-10-01 | 1,540 |
| 108 | 1.8 | **New Cryo Plant (Phase III @ NML)** |  | 781d | 2008-10-01 | 2011-09-28 |  | 198.8d |  |  | 12,453.85 |
| 109 | 1.8.1 | Procurement Process Phase 3 NML Cryo Plant |  | 3mo | 2008-10-01 | 2008-12-31 | 103 | 198.8d | 0d | start no earlier than 2008-10-01 |  |
| 110 | 1.8.2 | Award Contract for New Cryo Plant | milestone | 0d | 2008-12-31 | 2008-12-31 | 109 | 198.8d | 0d |  |  |
| 111 | 1.8.3 | Cryo Plant Phase Funded (Early Phase) |  | 24mo | 2009-01-01 | 2011-01-10 | 110 | 198.8d | 0d |  | 4,355 |
| 112 | 1.8.4 | Procure Phase 3 NML Cryo Plant (later Phase) |  | 15mo | 2009-10-06 | 2011-01-10 | 111FF | 198.8d | 0d | start no earlier than 2009-10-01 | 2,169 |
| 113 | 1.8.5 | Procure Distribution & Load Controls |  | 17.5mo | 2009-10-06 | 2011-03-28 | 112SS | 198.8d | 0d |  | 4,543.5 |
| 114 | 1.8.6 | Begin Installation Phase | milestone | 0d | 2011-03-28 | 2011-03-28 | 113, 112 | 198.8d | 0d |  |  |
| 115 | 1.8.7 | Install & Commission Phase 3 NML Cryo Plant |  | 6mo | 2011-03-29 | 2011-09-28 | 114 | 198.8d | 0d |  | 1,386.35 |
| 116 | 1.8.8 | Phase 3 Cryo Plant Ready for Operation | milestone | 0d | 2011-09-28 | 2011-09-28 | 115 | 198.8d |  |  |  |

| ID | WBS | Task | Type | Duration | Start | Finish | Predecessors | Total slack | Free slack | Constraint | Cost |
| --- | --- | --- | --- | --- | --- | --- | --- | --- | --- | --- | --- |
| 117 | 1.9 | **Illinois Accelerator Research Institute** |  | 1295.8d | 2007-07-17 | 2012-07-03 |  | 0d |  |  | 23,300 |
| 118 | 1.9.1 | Design IARC Infrastructure |  | 18mo | 2007-07-17 | 2009-01-20 |  | 0d |  | start no earlier than 2007-07-17 |  |
| 119 | 1.9.2 | IARC Building Begins Construction | milestone | 0d | 2009-01-20 | 2009-01-20 | 118 | 0d |  |  |  |
| 120 | 1.9.3 | Construct IARC Building |  | 18mo | 2009-01-21 | 2010-07-28 | 119 | 0d |  |  |  |
| 121 | 1.9.4 | IARC Building Complete | milestone | 0d | 2010-07-28 | 2010-07-28 | 120 | 239.8d |  |  |  |
| 122 | 1.9.5 | Procure Parts for IARC Infrastructure Phase 1 |  | 12mo | 2010-01-26 | 2011-01-28 | 120FS-6mo | 371.8d |  |  | 6,035 |
| 123 | 1.9.6 | Procure Parts for IARC Infrastructure Phase 2 |  | 19.9mo | 2010-01-26 | 2011-09-29 | 120FS-6mo | 0d |  |  | 12,485 |
| 124 | 1.9.7 | IARC Building Construction Complete | milestone | 0d | 2010-07-28 | 2010-07-28 | 120 | 503.8d |  |  |  |
| 125 | 1.9.8 | Install IARC Infrastructure |  | 12mo | 2011-06-29 | 2012-07-03 | 123FS-3mo, 121, 120 | 0d |  |  | 4,780 |
| 126 | 1.9.9 | IARC Ready for Operation | milestone | 0d | 2012-07-03 | 2012-07-03 | 125, 124 | 0d |  |  |  |
| 127 | 1.10 | **Material R&D** |  | 782d | 2006-10-02 | 2009-09-29 |  | 719.8d |  |  | 1,263.6 |
| 128 | 1.10.1 | Material R&D FY07 Finish Procurements |  | 52w | 2006-10-02 | 2007-09-28 |  | 1241.8d |  |  | 250 |
| 129 | 1.10.2 | Single Cell Setup FY07 |  | 52w | 2006-10-02 | 2007-09-28 |  | 1240.8d | 0d |  | 145.63 |
| 130 | 1.10.3 | Begin Single Cell Testing | milestone | 0d | 2007-10-01 | 2007-10-01 | 129FS+1d | 1240.8d |  |  |  |
| 131 | 1.10.4 | Single Cell Program FY08 |  | 52w | 2007-10-02 | 2008-09-29 |  | 980.8d |  | start no earlier than 2007-10-02 | 145.63 |
| 132 | 1.10.5 | Process R&D FY07 |  | 52w | 2006-10-02 | 2007-09-28 |  | 1241.8d |  |  | 49.52 |
| 133 | 1.10.6 | Process R&D FY08 |  | 52w | 2007-10-02 | 2008-09-29 |  | 980.8d |  | start no earlier than 2007-10-02 | 49.52 |
| 134 | 1.10.7 | Material Testing FY07 |  | 52w | 2006-10-02 | 2007-09-28 |  | 1241.8d |  |  | 136.9 |
| 135 | 1.10.8 | Material Testing FY08 |  | 52w | 2007-10-02 | 2008-09-29 |  | 980.8d |  | start no earlier than 2007-10-02 | 136.9 |
| 136 | 1.10.9 | Advanced R&D FY07 |  | 52w | 2006-10-02 | 2007-09-28 |  | 1241.8d |  | start no earlier than 2006-10-02 | 116.5 |
| 137 | 1.10.10 | Advanced R&D FY08 |  | 52w | 2007-10-02 | 2008-09-29 |  | 980.8d |  | start no earlier than 2007-10-02 | 116.5 |
| 138 | 1.10.11 | Advanced R&D FY09 |  | 52w | 2008-10-01 | 2009-09-29 |  | 719.8d |  | start no earlier than 2008-10-01 | 116.5 |
